# HRA Project Plan

Schedule from MS Project, 2011-10-31 to 2013-01-11, A marks actual dates.
Microsoft

## Calendars

- Standard: Mon-Fri 08:00-12:00, 13:00-17:00; Sat-Sun off. Exceptions (off unless hours are given): 2011-11-24 (Thanksgiving Day), 2011-11-25 (Thanksgiving Friday), 2011-12-23 (Special MIT Holiday 1), 2011-12-26 (Christmas Day Observed), 2011-12-30 (Special MIT Holiday 2), 2012-01-02 (New Years Day Observed), 2012-01-16 (Martin Luther King Birthday), 2012-02-20 (Presidents Day).

## Resources

| Resource |
| --- |
| Ross |
| Jonathan |
| Robin |

## Schedule

| ID | WBS | Task | Type | Duration | Start | Finish | Predecessors | Complete | Remaining | Total slack | Constraint | Resources | Work | Actual work |
| --- | --- | --- | --- | --- | --- | --- | --- | --- | --- | --- | --- | --- | --- | --- |
| 1 | 1 | **Housing Replacement Analysis Project** |  | 306.5d | 2011-10-31 A | 2013-01-11 |  | 15% | 260.57d | 0d |  |  | 1127.04h | 204.32h |
| 2 | 1.1 | Project Kickoff Meeting |  | 1d | 2011-10-31 | 2011-10-31 |  |  |  | 305.5d |  |  |  |  |
| 3 | 1.2 | **Discovery Phase (as-is)** |  | 217.5d | 2011-11-04 A | 2012-09-14 |  | 15% | 184.73d | 0d |  |  | 1127.04h | 204.32h |
| 4 | 1.2.1 | **Business Justification** |  | 20d | 2011-11-04 A | 2011-12-06 A | 2 | 100% |  |  |  |  | 136h | 136h |
| 5 | 1.2.1.1 | Write Business Justification |  | 10d | 2011-11-14 A | 2011-11-25 A | 6 | 100% |  |  | start no earlier than 2011-11-01 | Jonathan | 80h | 80h |
| 6 | 1.2.1.2 | Review Business Justification |  | 6d | 2011-11-04 A | 2011-11-11 A |  | 100% |  |  | finish no earlier than 2011-11-11 | Jonathan | 48h | 48h |
| 7 | 1.2.1.3 | Obtain Approval from Project Team |  | 1d | 2011-11-29 A | 2011-11-29 A | 5, 6 | 100% |  |  | start no earlier than 2011-11-29 | Jonathan | 8h | 8h |
| 8 | 1.2.1.4 | Obtain Approval from Project Sponsors | milestone | 0d | 2011-12-06 A | 2011-12-06 A | 7 | 100% |  |  | start no earlier than 2011-12-06 | Jonathan |  |  |
| 9 | 1.2.1.5 | Business Justification completed | milestone | 0d | 2011-12-06 A | 2011-12-06 A | 8 | 100% |  |  |  | Jonathan |  |  |
| 10 | 1.2.2 | **Project Scope Document** |  | 19d | 2011-11-07 A | 2011-12-06 A | 2 | 100% |  |  |  |  | 56h | 56h |
| 11 | 1.2.2.1 | Write Project Scope Document |  | 5d | 2011-11-07 A | 2011-11-11 A |  | 100% |  |  | finish no earlier than 2011-11-11 | Jonathan | 40h | 40h |
| 12 | 1.2.2.2 | Review Project Scope Document |  | 1d | 2011-11-18 A | 2011-11-18 A | 11 | 100% |  |  | finish no earlier than 2011-11-18 | Jonathan | 8h | 8h |
| 13 | 1.2.2.3 | Obtain Approval from Project Team |  | 1d | 2011-11-29 A | 2011-11-29 A |  | 100% |  |  | start no earlier than 2011-11-29 | Jonathan | 8h | 8h |
| 14 | 1.2.2.4 | Obtain Approval from Project Sponsors | milestone | 0d | 2011-12-06 A | 2011-12-06 A |  | 100% |  |  | start no earlier than 2011-12-06 | Jonathan |  |  |
| 15 | 1.2.2.5 | Project Scope completed | milestone | 0d | 2011-12-06 A | 2011-12-06 A |  | 100% |  |  | start no earlier than 2011-12-06 | Jonathan |  |  |
| 16 | 1.2.3 | **As-Is Process Maps** |  | 163.5d | 2011-12-15 A | 2012-08-08 | 4, 10 | 3% | 159.37d | 0d |  |  | 743.04h | 12.32h |
| 17 | 1.2.3.1 | System Diagram (IS&T) |  | 7d | 2011-12-15 A | 2012-02-03 |  | 50% | 3.5d | 0d | finish no earlier than 2012-02-03 | Ross [44%] | 24.64h | 12.32h |
| 18 | 1.2.3.2 | **Housing / Lottery** |  | 22d | 2012-02-06 | 2012-03-07 | 17 |  |  | 0d |  |  | 156.8h |  |
| 19 | 1.2.3.2.1 | Freshman (new to the Institute) |  | 2d | 2012-02-06 | 2012-02-07 |  |  |  | 0d |  | Ross [40%] | 6.4h |  |
| 20 | 1.2.3.2.2 | Upperclassman |  | 2d | 2012-02-08 | 2012-02-09 | 19 |  |  | 0d |  | Ross [40%] | 6.4h |  |
| 21 | 1.2.3.2.3 | FSILG |  | 2d | 2012-02-10 | 2012-02-13 | 20 |  |  | 0d |  | Ross | 16h |  |
| 22 | 1.2.3.2.4 | Off Campus Students |  | 2d | 2012-02-14 | 2012-02-15 | 21 |  |  | 0d |  | Ross | 16h |  |
| 23 | 1.2.3.2.5 | Graduate Students |  | 2d | 2012-02-16 | 2012-02-17 | 22 |  |  | 0d |  | Ross | 16h |  |
| 24 | 1.2.3.2.6 | Summer Students |  | 2d | 2012-02-21 | 2012-02-22 | 23 |  |  | 0d |  | Ross | 16h |  |
| 25 | 1.2.3.2.7 | Post-Doctoral / Faculty |  | 2d | 2012-02-23 | 2012-02-24 | 24 |  |  | 0d |  | Ross | 16h |  |
| 26 | 1.2.3.2.8 | Young Students (Legal Minors) |  | 2d | 2012-02-27 | 2012-02-28 | 25 |  |  | 0d |  | Ross | 16h |  |
| 27 | 1.2.3.2.9 | Outside, Non Affiliated Groups |  | 2d | 2012-02-29 | 2012-03-01 | 26 |  |  | 0d |  | Ross | 16h |  |
| 28 | 1.2.3.2.10 | MIT - Affiliated Groups |  | 2d | 2012-03-02 | 2012-03-05 | 27 |  |  | 0d |  | Ross | 16h |  |
| 29 | 1.2.3.2.11 | Visitors |  | 2d | 2012-03-06 | 2012-03-07 | 28 |  |  | 0d |  | Ross | 16h |  |

| ID | WBS | Task | Duration | Start | Finish | Predecessors | Total slack | Resources | Work |
| --- | --- | --- | --- | --- | --- | --- | --- | --- | --- |
| 30 | 1.2.3.3 | **Housing filemaker Databases** | 12d | 2012-03-08 | 2012-03-23 | 29 | 0d |  | 67.2h |
| 31 | 1.2.3.3.1 | Master Blaster | 2d | 2012-03-08 | 2012-03-09 |  | 0d | Ross [40%] | 6.4h |
| 32 | 1.2.3.3.2 | UG Confirmation | 2d | 2012-03-12 | 2012-03-13 | 31 | 0d | Ross [40%] | 6.4h |
| 33 | 1.2.3.3.3 | Conference / Guest | 2d | 2012-03-14 | 2012-03-15 | 32 | 0d | Ross [40%] | 6.4h |
| 34 | 1.2.3.3.4 | Vacancy | 2d | 2012-03-16 | 2012-03-19 | 33 | 0d | Ross | 16h |
| 35 | 1.2.3.3.5 | Early Return | 2d | 2012-03-20 | 2012-03-21 | 34 | 0d | Ross | 16h |
| 36 | 1.2.3.3.6 | Waiting List | 2d | 2012-03-22 | 2012-03-23 | 35 | 0d | Ross | 16h |
| 37 | 1.2.3.4 | Housing SISTIM Functionality on Housing | 15d | 2012-03-26 | 2012-04-13 | 36 | 0d | Ross | 120h |
| 38 | 1.2.3.5 | Housing MITSIS Functionality on Housing | 15d | 2012-04-16 | 2012-05-04 | 37 | 0d | Ross | 120h |
| 39 | 1.2.3.6 | **CBORD** | 18d | 2012-05-07 | 2012-05-30 | 38 | 0d |  | 57.6h |
| 40 | 1.2.3.6.1 | Digital Building / Room Setup & Maintenance | 6d | 2012-05-07 | 2012-05-14 |  | 0d | Ross [40%] | 19.2h |
| 41 | 1.2.3.6.2 | Room Rate Code Setup & Maintenance | 6d | 2012-05-15 | 2012-05-22 | 40 | 0d | Ross [40%] | 19.2h |
| 42 | 1.2.3.6.3 | Current Security, Roles & Authorization, and structures for housing applications | 6d | 2012-05-23 | 2012-05-30 | 41 | 0d | Ross [40%] | 19.2h |
| 43 | 1.2.3.7 | **Housing Stakeholder - HFS Accounting (David Bull's Group)** | 12d | 2012-05-31 | 2012-06-15 | 39 | 0d |  | 76.8h |
| 44 | 1.2.3.7.1 | Discuss systems/applications/process flow | 2d | 2012-05-31 | 2012-06-01 |  | 0d | Ross [40%] | 6.4h |
| 45 | 1.2.3.7.2 | Discuss process calendar | 2d | 2012-06-04 | 2012-06-05 | 44 | 0d | Ross [40%] | 6.4h |
| 46 | 1.2.3.7.3 | Walkthrough of digital Building/Room Setup & Maintenance | 2d | 2012-06-06 | 2012-06-07 | 45 | 0d | Ross | 16h |
| 47 | 1.2.3.7.4 | Walkthrough of Room Rate Codes Setup & Maintenance | 2d | 2012-06-08 | 2012-06-11 | 46 | 0d | Ross | 16h |
| 48 | 1.2.3.7.5 | Analysis/review of OTF process | 2d | 2012-06-12 | 2012-06-13 | 47 | 0d | Ross | 16h |
| 49 | 1.2.3.7.6 | Discuss functionality/efficiency/information gaps in current assessment & OTF process | 2d | 2012-06-14 | 2012-06-15 | 48 | 0d | Ross | 16h |
| 50 | 1.2.3.8 | **Housing Stakeholder - Student Financial Services** | 15d | 2012-06-18 | 2012-07-06 | 43 | 0d |  | 48h |
| 51 | 1.2.3.8.1 | Assess primary users/roles | 5d | 2012-06-18 | 2012-06-22 |  | 0d | Ross [40%] | 16h |
| 52 | 1.2.3.8.2 | Discuss systems/process flow | 5d | 2012-06-25 | 2012-06-29 | 51 | 0d | Ross [40%] | 16h |
| 53 | 1.2.3.8.3 | Discuss process calendar | 5d | 2012-07-02 | 2012-07-06 | 52 | 0d | Ross [40%] | 16h |

| ID | WBS | Task | Type | Duration | Start | Finish | Predecessors | Total slack | Resources | Work |
| --- | --- | --- | --- | --- | --- | --- | --- | --- | --- | --- |
| 54 | 1.2.3.9 | **Housing Stakeholder - Registrar** |  | 7.5d | 2012-07-09 | 2012-07-18 | 50 | 0d |  | 24h |
| 55 | 1.2.3.9.1 | Evaluate scope of affected data/process/systems |  | 2.5d | 2012-07-09 | 2012-07-11 |  | 0d | Ross [40%] | 8h |
| 56 | 1.2.3.9.2 | Examine dataflow for MITSIS Directory information |  | 2.5d | 2012-07-11 | 2012-07-13 | 55 | 0d | Ross [40%] | 8h |
| 57 | 1.2.3.9.3 | Examine current supporting processes & functionality |  | 2.5d | 2012-07-16 | 2012-07-18 | 56 | 0d | Ross [40%] | 8h |
| 58 | 1.2.3.10 | Housing Stakeholders - Card Office |  | 5d | 2012-07-18 | 2012-07-25 | 54 | 0d | Ross [40%] | 16h |
| 59 | 1.2.3.11 | Housing Stakeholders - Security and Emergency Office |  | 5d | 2012-07-25 | 2012-08-01 | 58 | 0d | Ross [40%] | 16h |
| 60 | 1.2.3.12 | Housing Stakeholders - Campus Dining |  | 5d | 2012-08-01 | 2012-08-08 | 59 | 0d | Ross [40%] | 16h |
| 61 | 1.2.3.13 | As-Is Process Maps completed | milestone | 0d | 2012-08-08 | 2012-08-08 | 18, 43, 60 | 0d | Ross |  |
| 62 | 1.2.4 | Review with Project Team, Stakeholders |  | 20d | 2012-08-08 | 2012-09-05 | 61 | 0d | Ross [40%]; Robin; Jonathan | 192h |
| 63 | 1.2.5 | Discovery Phase Completed | milestone | 0d | 2012-09-14 | 2012-09-14 | 62FS+7d | 0d |  |  |
| 64 | 1.3 | Define Phase | milestone | 0d | 2012-11-09 | 2012-11-09 | 3FS+40d | 0d |  |  |
| 65 | 1.4 | Design Phase | milestone | 0d | 2013-01-11 | 2013-01-11 | 64FS+45d | 0d |  |  |
